# Project Schedule

Schedule from Primavera P6, 2026-10-01 to 2027-07-01, data date 2026-10-01.
Must finish by 2027-07-01

## Calendars

- Corporate - Standard Full Time: Mon-Fri 08:00-16:00; Sat-Sun off.

## Schedule

| ID | WBS | Activity | Type | Duration | Start | Finish | Constraint |
| --- | --- | --- | --- | --- | --- | --- | --- |
| A0000 |  | Start Milestone | milestone | 0d | 2026-10-01 | 2026-10-01 |  |
| A1400 |  | Finish Milestone | milestone | 0d | 2027-07-01 | 2027-07-01 |  |
|  | 00 | **Underground** |  |  | 2026-10-05 | 2027-01-01 |  |
| A1010 |  | Continuous Footings |  | 21d | 2026-10-05 | 2026-11-02 | start on or after 2026-10-05 |
| A1030 |  | Spread Footings |  | 23d | 2026-11-04 | 2026-12-04 | start on or after 2026-11-04 |
| A1020 |  | Underground Walls |  | 27d | 2026-11-16 | 2026-12-22 | start on or after 2026-11-16 |
| A1100 |  | Underground Columns |  | 24d | 2026-12-01 | 2027-01-01 | start on or after 2026-12-01 |
|  | 01 | **First Floor** |  |  | 2026-12-14 | 2027-05-11 |  |
| A1050 |  | Slab on Grade |  | 25d | 2026-12-14 | 2027-01-15 | start on or after 2026-12-14 |
| A1040 |  | First Floor Walls |  | 20d | 2027-01-04 | 2027-01-29 | start on or after 2027-01-04 |
| A1110 |  | First Floor Columns |  | 26d | 2027-01-18 | 2027-02-22 | start on or after 2027-01-18 |
| A1200 |  | First Floor Ductwork |  | 20d | 2027-04-05 | 2027-04-30 | start on or after 2027-04-05 |
| A1300 |  | First Floor Pipework |  | 18d | 2027-04-12 | 2027-05-05 | start on or after 2027-04-12 |
| A1210 |  | First Floor HVAC Equipment |  | 10d | 2027-04-19 | 2027-04-30 | start on or after 2027-04-19 |
| A1310 |  | First Floor Plumbing Fixtures |  | 5d | 2027-05-05 | 2027-05-11 | start on or after 2027-05-05 |
|  | 02 | **Second Floor** |  |  | 2027-02-01 | 2027-05-21 |  |
| A1060 |  | Second Floor Walls |  | 20d | 2027-02-01 | 2027-02-26 | start on or after 2027-02-01 |
| A1120 |  | Second Floor Columns |  | 30d | 2027-02-15 | 2027-03-26 | start on or after 2027-02-15 |
| A1130 |  | Second Floor Framing |  | 15d | 2027-03-29 | 2027-04-16 | start on or after 2027-03-29 |
| A1220 |  | Second Floor Ductwork |  | 20d | 2027-04-19 | 2027-05-14 | start on or after 2027-04-19 |
| A1320 |  | Second Floor Pipework |  | 17d | 2027-04-23 | 2027-05-17 | start on or after 2027-04-23 |
| A1230 |  | Second Floor HVAC Equipment |  | 10d | 2027-05-03 | 2027-05-14 | start on or after 2027-05-03 |
| A1330 |  | Second Floor Plumbing Fixtures |  | 5d | 2027-05-17 | 2027-05-21 | start on or after 2027-05-17 |
|  | 03 | **Third Floor** |  |  | 2027-03-01 | 2027-07-01 |  |
| A1070 |  | Third Floor Walls |  | 20d | 2027-03-01 | 2027-03-26 | start on or after 2027-03-01 |
| A1140 |  | Third Floor Columns |  | 25d | 2027-03-22 | 2027-04-23 | start on or after 2027-03-22 |
| A1150 |  | Third Floor Framing |  | 6d | 2027-04-26 | 2027-05-03 | start on or after 2027-04-26 |
| A1240 |  | Third Floor Ductwork |  | 33d | 2027-05-05 | 2027-06-18 | start on or after 2027-05-05 |
| A1340 |  | Third Floor Pipework |  | 32d | 2027-05-07 | 2027-06-21 | start on or after 2027-05-07 |
| A1250 |  | Third Floor HVAC Equipment |  | 12d | 2027-06-16 | 2027-07-01 | start on or after 2027-06-16 |
| A1350 |  | Third Floor Plumbing Fixtures |  | 5d | 2027-06-21 | 2027-06-25 | start on or after 2027-06-21 |

| ID | WBS | Activity | Duration | Start | Finish | Constraint |
| --- | --- | --- | --- | --- | --- | --- |
|  | 04 | **Roof** |  | 2027-05-17 | 2027-06-25 |  |
| A1160 |  | Roof Framing | 15d | 2027-05-17 | 2027-06-04 | start on or after 2027-05-17 |
| A1360 |  | Roof Drain Pipework | 5d | 2027-06-07 | 2027-06-11 | start on or after 2027-06-07 |
| A1260 |  | Roof HVAC Equipment | 10d | 2027-06-14 | 2027-06-25 | start on or after 2027-06-14 |
